# Sample Project

Schedule from MS Project, 2015-07-16 to 2016-02-22, costs in $.
Wilmington University

## Calendars

- Standard: Mon-Fri 08:00-12:00, 13:00-17:00; Sat-Sun off.

## Resources

| Resource | Rate | Cost per use |
| --- | --- | --- |
| John | 50 |  |
| Mary | 50 |  |
| Administrative associate | 25 |  |
| Computer |  | 1500 |

## Schedule

| ID | WBS | Task | Type | Duration | Start | Finish | Predecessors | Total slack | Resources | Work | Cost |
| --- | --- | --- | --- | --- | --- | --- | --- | --- | --- | --- | --- |
| 1 | 1 | **PM Support to Romania: Year Two** |  | 158d | 2015-07-16 | 2016-02-22 |  | 0d |  | 736h | 35,100 |
| 2 | 1.1 | **Training curriculum refinement** |  | 12d | 2015-07-16 | 2015-07-31 |  | 0d |  | 60h | 4,500 |
| 3 | 1.1.1 | Review outcomes from year one training | manual | 3d | 2015-07-16 | 2015-07-20 |  |  | John; Computer | 12h | 2,100 |
| 4 | 1.1.2 | Amend curriculum to reflect lessons learned in outcomes | manual | 9d | 2015-07-21 | 2015-07-31 | 3 |  | John | 48h | 2,400 |
| 5 | 1.2 | **Translation of curriculum and support materials** |  | 5d | 2015-08-03 | 2015-08-07 |  | 0d |  | 19h | 600 |
| 6 | 1.2.1 | Contract for translator | manual | 1d | 2015-08-03 | 2015-08-03 | 4 |  | Administrative associate | 2h | 50 |
| 7 | 1.2.2 | Deliver updated curriculum and materials to translator | manual | 1d | 2015-08-04 | 2015-08-04 | 6 |  | Administrative associate | 5h | 125 |
| 8 | 1.2.3 | Review materials for publication | manual | 1d | 2015-08-05 | 2015-08-05 | 7 |  | Mary | 5h | 250 |
| 9 | 1.2.4 | Publish translated materials | manual | 2d | 2015-08-06 | 2015-08-07 | 8 |  | Administrative associate | 7h | 175 |
| 10 | 1.3 | **Training delivery** |  | 22d | 2015-08-10 | 2015-09-08 |  | 0d |  | 122h | 5,750 |
| 11 | 1.3.1 | Deliver training session one | manual | 4d | 2015-08-10 | 2015-08-13 | 9 |  | John | 24h | 1,200 |
| 12 | 1.3.2 | Deliver training session two | manual | 4d | 2015-08-14 | 2015-08-19 | 11 |  | John | 24h | 1,200 |
| 13 | 1.3.3 | Deliver training session three | manual | 4d | 2015-08-20 | 2015-08-25 | 12 |  | John | 24h | 1,200 |
| 14 | 1.3.4 | Deliver training session four | manual | 4d | 2015-08-26 | 2015-08-31 | 13 |  | John | 24h | 1,200 |
| 15 | 1.3.5 | Evaluate training outcomes | manual | 2d | 2015-09-01 | 2015-09-02 | 14 |  | John | 12h | 600 |
| 16 | 1.3.6 | Document training completions | manual | 1d | 2015-09-03 | 2015-09-03 | 15 |  | Administrative associate | 3h | 75 |
| 17 | 1.3.7 | Complete administrative procedures at College | manual | 1d | 2015-09-04 | 2015-09-04 | 16 |  | Administrative associate | 5h | 125 |
| 18 | 1.3.8 | Prepare certificates of completion | manual | 1d | 2015-09-07 | 2015-09-07 | 17 |  | Administrative associate | 5h | 125 |
| 19 | 1.3.9 | Issue certificated of completion | manual | 1d | 2015-09-08 | 2015-09-08 | 18 |  | Administrative associate | 1h | 25 |
| 20 | 1.4 | **Development and support of Romanian Project Risk Management Team** |  | 23d | 2015-09-09 | 2015-10-09 |  | 0d |  | 108h | 5,400 |
| 21 | 1.4.1 | Develop curriculum for risk team training | manual | 12d | 2015-09-09 | 2015-09-24 | 19 |  | Mary | 48h | 2,400 |
| 22 | 1.4.2 | Deliver materials to translator | manual | 1d | 2015-09-25 | 2015-09-25 | 21 |  | Mary | 5h | 250 |
| 23 | 1.4.3 | Prepare materials for publication | manual | 1d | 2015-09-28 | 2015-09-28 | 22 |  | Mary | 6h | 300 |
| 24 | 1.4.4 | Publish training materials | manual | 2d | 2015-09-29 | 2015-09-30 | 23 |  | Mary | 9h | 450 |
| 25 | 1.4.5 | Deliver risk team training session | manual | 4d | 2015-10-01 | 2015-10-06 | 24 |  | Mary | 24h | 1,200 |
| 26 | 1.4.6 | Evaluate training outcomes | manual | 2d | 2015-10-07 | 2015-10-08 | 25 |  | Mary | 12h | 600 |
| 27 | 1.4.7 | Provide follow up support to risk team | manual | 1d | 2015-10-09 | 2015-10-09 | 26 |  | Mary | 4h | 200 |

| ID | WBS | Task | Type | Duration | Start | Finish | Predecessors | Total slack | Resources | Work | Cost |
| --- | --- | --- | --- | --- | --- | --- | --- | --- | --- | --- | --- |
| 28 | 1.5 | **Development and support of Romanian Project Management Training Team** |  | 23d | 2015-10-12 | 2015-11-11 |  | 0d |  | 108h | 5,400 |
| 29 | 1.5.1 | Develop Train the Trainer curriculum | manual | 12d | 2015-10-12 | 2015-10-27 | 27 |  | John; Mary | 48h | 2,400 |
| 30 | 1.5.2 | Deliver materals to translator | manual | 1d | 2015-10-28 | 2015-10-28 | 29 |  | John; Mary | 5h | 250 |
| 31 | 1.5.3 | Prepare materials for publication | manual | 1d | 2015-10-29 | 2015-10-29 | 30 |  | John; Mary | 6h | 300 |
| 32 | 1.5.4 | Publish training materials | manual | 2d | 2015-10-30 | 2015-11-02 | 31 |  | John; Mary | 9h | 450 |
| 33 | 1.5.5 | Deliver Train the Trainer course | manual | 4d | 2015-11-03 | 2015-11-06 | 32 |  | John; Mary | 24h | 1,200 |
| 34 | 1.5.6 | Evaluate training outcomes | manual | 2d | 2015-11-09 | 2015-11-10 | 33 |  | John; Mary | 12h | 600 |
| 35 | 1.5.7 | Provide follow up support to training team | manual | 1d | 2015-11-11 | 2015-11-11 | 34 |  | John; Mary | 4h | 200 |
| 36 | 1.6 | **Critique of Romanian-developed plans** |  | 28d | 2015-11-12 | 2015-12-21 |  | 0d |  | 138h | 6,450 |
| 37 | 1.6.1 | Develop outcomes evaluation materials | manual | 8d | 2015-11-12 | 2015-11-23 | 35 |  | John | 24h | 1,200 |
| 38 | 1.6.2 | Send materials to translator | manual | 1d | 2015-11-24 | 2015-11-24 | 37 |  | Administrative associate | 5h | 125 |
| 39 | 1.6.3 | Prepare materials for publication | manual | 1d | 2015-11-25 | 2015-11-25 | 38 |  | Administrative associate | 6h | 150 |
| 40 | 1.6.4 | Publish materials | manual | 2d | 2015-11-26 | 2015-11-27 | 39 |  | Administrative associate | 7h | 175 |
| 41 | 1.6.5 | Conduct on site critiques session one | manual | 4d | 2015-11-30 | 2015-12-03 | 40 |  | Mary | 24h | 1,200 |
| 42 | 1.6.6 | Conduct on site critiques session two | manual | 4d | 2015-12-04 | 2015-12-09 | 41 |  | Mary | 24h | 1,200 |
| 43 | 1.6.7 | Conduct on site critiques session three | manual | 4d | 2015-12-10 | 2015-12-15 | 42 |  | Mary | 24h | 1,200 |
| 44 | 1.6.8 | Conduct on site critiques sessin four | manual | 4d | 2015-12-16 | 2015-12-21 | 43 |  | Mary | 24h | 1,200 |
| 45 | 1.7 | **On site technical assistance in executing, monitoring, controlling, and closing projects** |  | 13d | 2015-12-22 | 2016-01-07 |  | 0d |  | 68h | 3,400 |
| 46 | 1.7.1 | Conduct on site assistance session one | manual | 1d | 2015-12-22 | 2015-12-22 | 44 |  | John; Mary | 6h | 300 |
| 47 | 1.7.2 | Conduct on site assistance session two | manual | 1d | 2015-12-23 | 2015-12-23 | 46 |  | John; Mary | 6h | 300 |
| 48 | 1.7.3 | Conduct on site assistance session three | manual | 1d | 2015-12-24 | 2015-12-24 | 47 |  | John; Mary | 6h | 300 |
| 49 | 1.7.4 | Identify topics and develop syllabus for enhanced video training package and handbook to be translated into Romanian, for use by Romanian trainers and users | manual | 4d | 2015-12-25 | 2015-12-30 | 48 |  | John; Mary | 12h | 600 |
| 50 | 1.7.5 | Identify topics for inclusion in video package | manual | 1d | 2015-12-31 | 2015-12-31 | 49 |  | John; Mary | 4h | 200 |
| 51 | 1.7.6 | Prepare video scripts and PowerPoint presentations | manual | 5d | 2016-01-01 | 2016-01-07 | 50 |  | John; Mary | 34h | 1,700 |

| ID | WBS | Task | Type | Duration | Start | Finish | Predecessors | Total slack | Resources | Work | Cost |
| --- | --- | --- | --- | --- | --- | --- | --- | --- | --- | --- | --- |
| 52 | 1.8 | **Contract for video development and production** |  | 26d | 2016-01-08 | 2016-02-12 |  | 0d |  | 87h | 2,300 |
| 53 | 1.8.1 | Record video | manual | 1d | 2016-01-08 | 2016-01-08 | 51 |  | Mary | 5h | 250 |
| 54 | 1.8.2 | Edit video | manual | 5d | 2016-01-11 | 2016-01-15 | 53 |  | Administrative associate | 12h | 300 |
| 55 | 1.8.3 | Send video to translator | manual | 1d | 2016-01-18 | 2016-01-18 | 54 |  | Administrative associate | 4h | 100 |
| 56 | 1.8.4 | Package video for DVD distribution | manual | 4d | 2016-01-19 | 2016-01-22 | 55 |  | Administrative associate | 12h | 300 |
| 57 | 1.8.5 | Develop supporting manual for video package | manual | 9d | 2016-01-25 | 2016-02-04 | 56 |  | Administrative associate | 34h | 850 |
| 58 | 1.8.6 | Send maual to translator | manual | 1d | 2016-02-05 | 2016-02-05 | 57 |  | Administrative associate | 4h | 100 |
| 59 | 1.8.7 | Prepare package for publication | manual | 2d | 2016-02-08 | 2016-02-09 | 58 |  | Administrative associate | 6h | 150 |
| 60 | 1.8.8 | Publish package | manual | 1d | 2016-02-10 | 2016-02-10 | 59 |  | Administrative associate | 4h | 100 |
| 61 | 1.8.9 | Distribute package | manual | 2d | 2016-02-11 | 2016-02-12 | 60 |  | Administrative associate | 6h | 150 |
| 62 | 1.9 | **Assistance to Romanian participants in developing sustainable project management system and training program to support it** |  | 6d | 2016-02-15 | 2016-02-22 |  | 0d |  | 26h | 1,300 |
| 63 | 1.9.1 | Review progress to date | manual | 1d | 2016-02-15 | 2016-02-15 | 61 |  | John; Mary | 6h | 300 |
| 64 | 1.9.2 | Research sustainility options | manual | 4d | 2016-02-16 | 2016-02-19 | 63 |  | Mary | 16h | 800 |
| 65 | 1.9.3 | Make recommendations to Romanian participants | manual | 1d | 2016-02-22 | 2016-02-22 | 64 |  | John | 4h | 200 |
